# VOORBEREIDING BOVENBOUWFASE

Schedule from MS Project, 2003-01-12 to 2003-04-15, status date 2003-01-08.
BAM Nelissen Van Egteren

## Calendars

- ALLEEN WERKDAGEN: Mon-Fri 08:30-12:30, 13:00-17:00; Sat-Sun off. Exceptions (off unless hours are given): 2003-01-11 to 2003-01-12 08:30-12:30, 13:00-17:00, 2003-01-18 to 2003-01-19 08:30-12:30, 13:00-17:00, 2003-01-25 to 2003-01-26 08:30-12:30, 13:00-17:00, 2003-02-01 to 2003-02-02 08:30-12:30, 13:00-17:00, 2003-02-08 to 2003-02-09 08:30-12:30, 13:00-17:00, 2003-02-15 to 2003-02-16 08:30-12:30, 13:00-17:00, 2003-02-22 to 2003-02-23 08:30-12:30, 13:00-17:00, 2003-03-01 to 2003-03-02 08:30-12:30, 13:00-17:00, 2003-03-08 to 2003-03-09 08:30-12:30, 13:00-17:00, 2003-03-15 to 2003-03-16 08:30-12:30, 13:00-17:00, 2003-03-22 to 2003-03-23 08:30-12:30, 13:00-17:00, 2003-03-29 to 2003-03-30 08:30-12:30, 13:00-17:00, 2003-04-05 to 2003-04-06 08:30-12:30, 13:00-17:00, 2003-04-12 to 2003-04-13 08:30-12:30, 13:00-17:00.

## Schedule

| ID | WBS | Task | Type | Duration | Start | Finish | Predecessors | Total slack | Free slack |
| --- | --- | --- | --- | --- | --- | --- | --- | --- | --- |
| 1 | 1 | **INSITU BETONSKELET** |  | 70d | 2003-01-12 | 2003-03-22 |  | 24d |  |
| 2 | 1.1 | bouwopdracht | milestone | 0d | 2003-01-12 | 2003-01-12 |  | 94d |  |
| 3 | 1.2 | **vormtek. wanden+kolommen** |  | 20d | 2003-01-12 | 2003-01-31 |  | 24d |  |
| 4 | 1.2.1 | betonvormtekening concept |  | 10d | 2003-01-12 | 2003-01-21 |  | 24d | 0d |
| 5 | 1.2.2 | controle vormtekeningen |  | 5d | 2003-01-22 | 2003-01-26 | 4 | 24d | 0d |
| 6 | 1.2.3 | betonvormtekening definitief |  | 5d | 2003-01-27 | 2003-01-31 | 5 | 24d | 0d |
| 7 | 1.3 | **vormtek. Verdiepingsvloer** |  | 20d | 2003-01-17 | 2003-02-05 |  | 41d |  |
| 8 | 1.3.1 | betonvormtekening concept |  | 10d | 2003-01-17 | 2003-01-26 | 4SS+5d | 41d | 0d |
| 9 | 1.3.2 | controle vormtekeningen |  | 5d | 2003-01-27 | 2003-01-31 | 8 | 49d | 0d |
| 10 | 1.3.3 | betonvormtekening definitief |  | 5d | 2003-02-01 | 2003-02-05 | 9 | 49d | 0d |
| 11 | 1.4 | **sparingstek. Verdiepingsvloer** |  | 20d | 2003-02-06 | 2003-02-25 |  | 49d |  |
| 12 | 1.4.1 | betonvormtekening concept |  | 10d | 2003-02-06 | 2003-02-15 | 10 | 49d | 0d |
| 13 | 1.4.2 | controle vormtekeningen |  | 5d | 2003-02-16 | 2003-02-20 | 12 | 49d | 0d |
| 14 | 1.4.3 | betonvormtekening definitief |  | 5d | 2003-02-21 | 2003-02-25 | 13 | 49d |  |
| 15 | 1.5 | **bekistingstekening** |  | 38d | 2003-01-27 | 2003-03-05 |  | 41d |  |
| 16 | 1.5.1 | bekistingssysteem bepalen |  | 5d | 2003-01-27 | 2003-01-31 | 8 | 41d | 0d |
| 17 | 1.5.2 | bekistingstekening concept |  | 5d | 2003-02-01 | 2003-02-05 | 16 | 41d | 0d |
| 18 | 1.5.3 | controle bekistingstekening |  | 5d | 2003-02-06 | 2003-02-10 | 17 | 41d | 0d |
| 19 | 1.5.4 | bekistingstekening definitief |  | 3d | 2003-02-11 | 2003-02-13 | 18 | 41d | 0d |
| 20 | 1.5.5 | levertijd bekistingen |  | 20d | 2003-02-14 | 2003-03-05 | 19 | 41d |  |
| 21 | 1.5.6 | start bekistingswerk | milestone | 0d | 2003-03-05 | 2003-03-05 | 20 | 41d |  |
| 22 | 1.6 | **wapeningstekening** |  | 20d | 2003-02-01 | 2003-02-20 |  | 24d |  |
| 23 | 1.6.1 | wapeningstekening concept |  | 10d | 2003-02-01 | 2003-02-10 | 6 | 24d | 0d |
| 24 | 1.6.2 | controle wapeningstekening |  | 5d | 2003-02-11 | 2003-02-15 | 23 | 24d | 0d |
| 25 | 1.6.3 | wapeningstekening definitief |  | 5d | 2003-02-16 | 2003-02-20 | 24 | 24d | 0d |

| ID | WBS | Task | Type | Duration | Start | Finish | Predecessors | Total slack | Free slack |
| --- | --- | --- | --- | --- | --- | --- | --- | --- | --- |
| 26 | 1.7 | **buigstaten** |  | 30d | 2003-02-21 | 2003-03-22 |  | 24d |  |
| 27 | 1.7.1 | buigstaten concept |  | 10d | 2003-02-21 | 2003-03-02 | 25 | 24d | 0d |
| 28 | 1.7.2 | controle buigstaten |  | 5d | 2003-03-03 | 2003-03-07 | 27 | 24d | 0d |
| 29 | 1.7.3 | buigstaten definitief |  | 5d | 2003-03-08 | 2003-03-12 | 28 | 24d | 0d |
| 30 | 1.7.4 | levertijd wapening |  | 10d | 2003-03-13 | 2003-03-22 | 29 | 24d | 0d |
| 31 | 1.7.5 | start insitu betonskelet | milestone | 0d | 2003-03-22 | 2003-03-22 | 30 | 24d |  |
| 33 | 2 | **PREFAB VLOER ELEMENTEN** |  | 55d | 2003-01-12 | 2003-03-07 |  | 39d |  |
| 34 | 2.1 | bouwopdracht | milestone | 0d | 2003-01-12 | 2003-01-12 |  | 39d | 0d |
| 35 | 2.2 | **vormtekening elementen** |  | 20d | 2003-01-12 | 2003-01-31 |  | 39d |  |
| 36 | 2.2.1 | vormtekening concept |  | 10d | 2003-01-12 | 2003-01-21 | 34 | 39d | 0d |
| 37 | 2.2.2 | controle vormtekening |  | 5d | 2003-01-22 | 2003-01-26 | 36 | 59d | 0d |
| 38 | 2.2.3 | vormtekening definitief |  | 5d | 2003-01-27 | 2003-01-31 | 37 | 59d | 0d |
| 39 | 2.3 | **sparingstekening** |  | 15d | 2003-02-01 | 2003-02-15 | 38 | 59d |  |
| 40 | 2.3.1 | speringstek. Concept |  | 5d | 2003-02-01 | 2003-02-05 |  | 59d | 0d |
| 41 | 2.3.2 | controle sparingstekening |  | 5d | 2003-02-06 | 2003-02-10 | 40 | 59d | 0d |
| 42 | 2.3.3 | sparingstekening definitief |  | 5d | 2003-02-11 | 2003-02-15 | 41 | 59d |  |
| 43 | 2.4 | **leverancier prefab elementen** |  | 25d | 2003-01-22 | 2003-02-15 |  | 39d |  |
| 44 | 2.4.1 | prijsaanvraag prefab vloer opstellen |  | 3d | 2003-01-22 | 2003-01-24 | 36 | 39d | 0d |
| 45 | 2.4.2 | offertes vragen prefab lev |  | 3d | 2003-01-25 | 2003-01-27 | 44 | 39d | 0d |
| 46 | 2.4.3 | lev, prijsaanbieding maken |  | 7d | 2003-01-28 | 2003-02-03 | 45 | 39d | 0d |
| 47 | 2.4.4 | offertes prefab beoordelen |  | 3d | 2003-02-04 | 2003-02-06 | 46 | 39d | 0d |
| 48 | 2.4.5 | prijsonderhandeling met lev. |  | 5d | 2003-02-07 | 2003-02-11 | 47 | 39d | 0d |
| 49 | 2.4.6 | leveringsopdracht opstellen |  | 3d | 2003-02-12 | 2003-02-14 | 48 | 39d | 0d |
| 50 | 2.4.7 | opdracht aan betonfabriek |  | 1d | 2003-02-15 | 2003-02-15 | 49 | 39d | 0d |

| ID | WBS | Task | Type | Duration | Start | Finish | Predecessors | Total slack | Free slack |
| --- | --- | --- | --- | --- | --- | --- | --- | --- | --- |
| 51 | 2.5 | **productie elementen** |  | 20d | 2003-02-16 | 2003-03-07 |  | 39d |  |
| 52 | 2.5.1 | voorbereiding productie |  | 10d | 2003-02-16 | 2003-02-25 | 50 | 39d | 0d |
| 53 | 2.5.2 | elementen produceren |  | 10d | 2003-02-26 | 2003-03-07 | 52 | 39d | 0d |
| 54 | 2.5.3 | start montage prefab elementen | milestone | 0d | 2003-03-07 | 2003-03-07 | 53 | 39d |  |
| 56 | 3 | **PREFAB BETON SKELET** |  | 85d | 2003-01-12 | 2003-04-06 |  | 9d |  |
| 57 | 3.1 | bouwopdracht | milestone | 0d | 2003-01-12 | 2003-01-12 |  | 9d | 0d |
| 58 | 3.2 | **vormtekening elementen** |  | 20d | 2003-01-12 | 2003-01-31 |  | 9d |  |
| 59 | 3.2.1 | vormtekening concept |  | 10d | 2003-01-12 | 2003-01-21 | 57 | 9d | 0d |
| 60 | 3.2.2 | controle vormtekening |  | 5d | 2003-01-22 | 2003-01-26 | 59 | 59d | 0d |
| 61 | 3.2.3 | vormtekening definitief |  | 5d | 2003-01-27 | 2003-01-31 | 60 | 59d | 0d |
| 62 | 3.3 | **sparingstekening** |  | 15d | 2003-02-01 | 2003-02-15 | 61 | 59d |  |
| 63 | 3.3.1 | speringstek. Concept |  | 5d | 2003-02-01 | 2003-02-05 |  | 59d | 0d |
| 64 | 3.3.2 | controle sparingstekening |  | 5d | 2003-02-06 | 2003-02-10 | 63 | 59d | 0d |
| 65 | 3.3.3 | sparingstekening definitief |  | 5d | 2003-02-11 | 2003-02-15 | 64 | 59d |  |
| 66 | 3.4 | **leverancier prefab elementen** |  | 25d | 2003-01-22 | 2003-02-15 |  | 9d |  |
| 67 | 3.4.1 | prijsaanvraag prefab opstellen |  | 3d | 2003-01-22 | 2003-01-24 | 59 | 9d | 0d |
| 68 | 3.4.2 | offertes bij lev, aanvragen |  | 3d | 2003-01-25 | 2003-01-27 | 67 | 9d | 0d |
| 69 | 3.4.3 | lev. Prijsaanbieding maken |  | 7d | 2003-01-28 | 2003-02-03 | 68 | 9d | 0d |
| 70 | 3.4.4 | offertes prefab beoordelen |  | 3d | 2003-02-04 | 2003-02-06 | 69 | 9d | 0d |
| 71 | 3.4.5 | prijsonderhandeling met lev,prefab |  | 5d | 2003-02-07 | 2003-02-11 | 70 | 9d | 0d |
| 72 | 3.4.6 | leveringscontract opstellen |  | 3d | 2003-02-12 | 2003-02-14 | 71 | 9d | 0d |
| 73 | 3.4.7 | opdracht aan betonfabriek |  | 1d | 2003-02-15 | 2003-02-15 | 72 | 9d | 0d |
| 74 | 3.5 | **productie elementen** |  | 50d | 2003-02-16 | 2003-04-06 |  | 9d |  |
| 75 | 3.5.1 | productietek. concept maken |  | 20d | 2003-02-16 | 2003-03-07 | 73 | 9d | 0d |
| 76 | 3.5.2 | controle productietekening |  | 10d | 2003-03-03 | 2003-03-12 | 75SS+15d | 9d | 0d |
| 77 | 3.5.3 | productietekening definitief |  | 10d | 2003-03-08 | 2003-03-17 | 76SS+5d | 9d | 0d |
| 78 | 3.5.4 | voorbereiding productie |  | 10d | 2003-03-18 | 2003-03-27 | 77 | 9d | 0d |
| 79 | 3.5.5 | 1e elementen produceren |  | 10d | 2003-03-28 | 2003-04-06 | 78 | 9d | 0d |
| 80 | 3.5.6 | start montage prefab elementen | milestone | 0d | 2003-04-06 | 2003-04-06 | 79 | 9d |  |

| ID | WBS | Task | Type | Duration | Start | Finish | Predecessors | Total slack | Free slack |
| --- | --- | --- | --- | --- | --- | --- | --- | --- | --- |
| 82 | 4 | **STAALCONSTRUCTIE SKELET** |  | 94d | 2003-01-12 | 2003-04-15 |  | 0d |  |
| 83 | 4.1 | bouwopdracht | milestone | 0d | 2003-01-12 | 2003-01-12 |  | 0d |  |
| 84 | 4.2 | bestektek. Staalconstructie |  | 5d | 2003-01-12 | 2003-01-16 | 83 | 0d |  |
| 85 | 4.3 | **staalconstructie bedrijf** |  | 24d | 2003-01-17 | 2003-02-09 |  | 0d |  |
| 86 | 4.3.1 | prijsaanvraag staalwerk opstellen |  | 3d | 2003-01-17 | 2003-01-19 | 84 | 0d |  |
| 87 | 4.3.2 | offertes bij staalbedrijven vragen |  | 3d | 2003-01-20 | 2003-01-22 | 86 | 0d |  |
| 88 | 4.3.3 | lev. Prijsaanbieding maken |  | 7d | 2003-01-23 | 2003-01-29 | 87 | 0d |  |
| 89 | 4.3.4 | offertes staalwerk beoordelen |  | 3d | 2003-01-30 | 2003-02-01 | 88 | 0d |  |
| 90 | 4.3.5 | prijsonderhandeling met staalbedrijf |  | 5d | 2003-02-02 | 2003-02-06 | 89 | 0d |  |
| 91 | 4.3.6 | leveringscontract opstellen |  | 3d | 2003-02-07 | 2003-02-09 | 90 | 0d |  |
| 92 | 4.3.7 | opdracht aan staalbedrijf | milestone | 0d | 2003-02-09 | 2003-02-09 | 91 | 0d |  |
| 93 | 4.4 | **productietekeningen staalskelet** |  | 30d | 2003-02-10 | 2003-03-11 |  | 0d |  |
| 94 | 4.4.1 | productietek. Concept maken |  | 20d | 2003-02-10 | 2003-03-01 | 92 | 0d |  |
| 95 | 4.4.2 | controle productietekening |  | 10d | 2003-02-25 | 2003-03-06 | 94SS+15d | 0d |  |
| 96 | 4.4.3 | productietek. Definitief maken |  | 10d | 2003-03-02 | 2003-03-11 | 95SS+5d | 0d |  |
| 97 | 4.5 | **ankers voor fundatie** |  | 25d | 2003-02-20 | 2003-03-16 |  | 30d |  |
| 98 | 4.5.1 | ankerplan maken |  | 5d | 2003-02-20 | 2003-02-24 | 94SS+10d | 30d | 0d |
| 99 | 4.5.2 | productie ankers |  | 10d | 2003-02-25 | 2003-03-06 | 98 | 30d | 0d |
| 100 | 4.5.3 | instorten ankers fundering |  | 10d | 2003-03-07 | 2003-03-16 | 99 | 30d |  |
| 101 | 4.6 | **productie staalskelet** |  | 35d | 2003-03-12 | 2003-04-15 |  | 0d |  |
| 102 | 4.6.1 | voorbereiding productie |  | 15d | 2003-03-12 | 2003-03-26 | 96 | 0d |  |
| 103 | 4.6.2 | produceren staalconstructie |  | 20d | 2003-03-27 | 2003-04-15 | 102 | 0d |  |
| 104 | 4.6.3 | start montage staalskelet | milestone | 0d | 2003-04-15 | 2003-04-15 | 103 | 0d |  |
